# WNA_Bln_Hohensaaten

Schedule from MS Project, 2027-01-11 to 2029-06-06.
KuK

## Calendars

- Standard: Mon-Fri 08:00-12:00, 13:00-17:00; Sat-Sun off. Exceptions (off unless hours are given): 2026-01-01 to 2035-07-28 (Wochenende, recurring), 2027-03-26, 2027-03-29, 2027-05-06, 2027-05-17, 2028-04-14, 2028-04-17, 2028-05-01, 2028-05-28, 2028-06-05, 2028-10-03, 2028-12-24 to 2028-12-26, 2028-12-31 to 2029-01-01, 2029-03-08, 2029-03-30, 2029-04-02, 2029-05-01, 2029-05-10, 2029-05-21.

## Resources

| Resource |
| --- |
| Telekom |
| AG SB7 |
| BMDV/ GDWS |
| GDWS |
| AG SB2 |
| Bieter |
| AG |
| AN |
| AN Büro |
| AN/AG |
| Stromnetz |
| Versatel |
| BWB |
| Alliander |
| euNetworks |

## Schedule

| ID | WBS | Task | Type | Duration | Start | Finish | Predecessors | Total slack | Constraint |
| --- | --- | --- | --- | --- | --- | --- | --- | --- | --- |
| 1 | 1 | **Ersatzneubau Techowbrücke** |  | 610d | 2027-01-11 | 2029-06-06 |  | 0d |  |
| 2 | 1.1 | Technische Bearbeitung inkl. Prüfung durch AG |  | 190d | 2027-01-11 | 2027-10-07 |  | 0d | start no earlier than 2027-01-11 |
| 3 | 1.2 | **Baudurchführung** |  | 540d | 2027-04-21 | 2029-06-06 |  | 0d |  |
| 4 | 1.2.1 | Werksfertigung Stahlbau |  | 120d | 2027-10-08 | 2028-03-23 | 2 | 5d | start no earlier than 2027-09-14 |
| 5 | 1.2.2 | Bauphase 1 - BE, Verkehrslenkung und diverses zur Bauvorbereitung |  | 55d | 2027-04-21 | 2027-07-08 | 2FS-120d | 0d | start no earlier than 2027-03-24 |
| 6 | 1.2.3 | Bauphase 2 - Herstellen Baugrubenverbau |  | 25d | 2027-07-09 | 2027-08-12 | 5 | 0d |  |
| 7 | 1.2.4 | Bauphase 3 - Abbruch Überbau Bestand |  | 40d | 2027-08-13 | 2027-10-07 | 6 | 0d |  |
| 8 | 1.2.5 | Bauphase 4 - Abbruch Mittelpfeiler und Widerlager |  | 20d | 2027-10-08 | 2027-11-04 | 7 | 0d |  |
| 9 | 1.2.6 | Bauphase 5 - Herstellung Baugruben und Widerlager |  | 115d | 2027-11-05 | 2028-04-13 | 8 | 0d |  |
| 10 | 1.2.7 | Bauphase 6 - Montage Längsträger u. Herstellung Überbau |  | 85d | 2028-04-18 | 2028-08-16 | 9, 4FS+10d | 0d |  |
| 11 | 1.2.8 | Bauphase 7 - Fertigstellung Überbau und Leitungsarbeiten |  | 110d | 2028-08-17 | 2029-01-23 | 10 | 0d |  |
| 12 | 1.2.9 | Bauphase 8 - Straßenbau, Landschaftsarbeiten etc. |  | 90d | 2029-01-24 | 2029-06-06 | 11 | 0d |  |
| 13 | 1.3 | Abschluss Bauleistung | milestone | 1d | 2029-06-06 | 2029-06-06 | 12FS-1d | 0d |  |

Notes:
- 1: Hinweis: Es sind Feiertage für Berlin als arbeitsfreie Tage hinterlegt.
